Schedule from MS Project, 2020-01-06 to 2020-11-20.

## Calendars

- Standard: Mon-Fri 08:00-12:00, 13:00-17:00; Sat-Sun off.

## Resources

| Resource |
| --- |
| ARC |
| STE |
| DEV |
| QC |

## Schedule

| ID | Task | Type | Duration | Start | Finish | Predecessors | Total slack | Free slack | Resources | Work | PDEx Abnormal Activity |
| --- | --- | --- | --- | --- | --- | --- | --- | --- | --- | --- | --- |
| 1 | Fuzzy Front End |  | 20d | 2020-01-06 | 2020-01-31 |  | 0d |  | ARC | 160h | Yes |
| 2 | SDP Review | milestone | 0d | 2020-01-31 | 2020-01-31 | 1 | 0d |  |  |  | Yes |
| 3 | Test Plan |  | 15d | 2020-02-03 | 2020-02-21 | 2 | 170d | 0d | STE | 120h |  |
| 4 | Test Harness |  | 10d | 2020-02-24 | 2020-03-06 | 3 | 170d |  | STE | 80h | Yes |
| 5 | Logging |  | 15d | 2020-02-03 | 2020-02-21 | 2 | 0d |  | DEV | 120h |  |
| 6 | Security |  | 15d | 2020-02-24 | 2020-03-13 | 5 | 0d |  | DEV | 120h |  |
| 7 | Pub/Sub |  | 15d | 2020-03-16 | 2020-04-03 | 6 | 0d |  | DEV | 120h |  |
| 8 | Resource Access 1 |  | 15d | 2020-04-06 | 2020-04-24 | 7 | 0d |  | DEV | 120h |  |
| 9 | Resource Access 2 |  | 15d | 2020-04-27 | 2020-05-15 | 8 | 0d |  | DEV | 120h |  |
| 10 | Resource Access 3 |  | 15d | 2020-05-18 | 2020-06-05 | 9 | 0d |  | DEV | 120h |  |
| 11 | EngineA |  | 15d | 2020-06-08 | 2020-06-26 | 10 | 0d |  | DEV | 120h |  |
| 12 | EngineB |  | 15d | 2020-06-29 | 2020-07-17 | 11 | 0d |  | DEV | 120h |  |
| 13 | EngineC |  | 15d | 2020-07-20 | 2020-08-07 | 12 | 0d |  | DEV | 120h |  |
| 14 | ManagerA |  | 15d | 2020-08-10 | 2020-08-28 | 13 | 0d |  | DEV | 120h |  |
| 15 | ManagerB |  | 15d | 2020-08-31 | 2020-09-18 | 14 | 0d |  | DEV | 120h |  |
| 16 | Client App1 |  | 15d | 2020-09-21 | 2020-10-09 | 15 | 0d |  | DEV | 120h |  |
| 17 | Client App2 |  | 15d | 2020-10-12 | 2020-10-30 | 16 | 0d |  | DEV | 120h |  |
| 18 | System Testing |  | 15d | 2020-11-02 | 2020-11-20 | 17, 4 | 0d |  | QC | 120h |  |
