# IDesign Inc.

Schedule from MS Project, 2013-01-28 to 2013-10-25.

## Calendars

- Standard: Mon-Fri 08:00-12:00, 13:00-17:00; Sat-Sun off.

## Resources

| Resource |
| --- |
| Project Manager |
| Architect |
| Prodcut Manager |
| Developer 1 |
| Developer 2 |
| Developer 3 |
| Developer 4 |
| Developer 5 |
| QC 1 |
| QC 2 |
| Test Engineer 1 |
| DBA 1 |
| DBA2 |

## Schedule

| ID | Task | Duration | Start | Finish | Predecessors | Total slack | Free slack | PDEx Message | PDEx Abnormal Activity |
| --- | --- | --- | --- | --- | --- | --- | --- | --- | --- |
| 1 | Requirements | 15d | 2013-01-28 | 2013-02-15 |  | 0d |  | [Owner Error] |  |
| 2 | Architecture | 20d | 2013-02-18 | 2013-03-15 | 1 | 0d |  | [Owner Error] |  |
| 3 | Project Design | 20d | 2013-03-18 | 2013-04-12 | 2 | 0d |  | [Owner Error] |  |
| 4 | Test Plan | 30d | 2013-04-15 | 2013-05-24 | 3 | 45d | 0d | [Owner Error] | Yes |
| 5 | Test Harness | 35d | 2013-05-27 | 2013-07-12 | 4 | 45d |  | [Owner Error] | Yes |
| 6 | Logging | 15d | 2013-04-15 | 2013-05-03 | 3 | 0d |  | [Owner Error] |  |
| 7 | Security | 20d | 2013-04-15 | 2013-05-10 | 3 | 35d |  | [Owner Error] |  |
| 8 | Pub/Sub | 5d | 2013-04-15 | 2013-04-19 | 3 | 50d |  | [Owner Error] | Yes |
| 9 | Resource A | 20d | 2013-04-15 | 2013-05-10 | 3 | 25d | 0d | [Owner Error] |  |
| 10 | Resource B | 15d | 2013-04-15 | 2013-05-03 | 3 | 10d | 0d | [Owner Error] |  |
| 11 | Resource Access A | 10d | 2013-05-13 | 2013-05-24 | 6, 9 | 25d |  | [Owner Error] | Yes |
| 12 | Resource Access B | 5d | 2013-05-06 | 2013-05-10 | 10, 6 | 10d |  | [Owner Error] | Yes |
| 13 | Resource Access C | 15d | 2013-05-06 | 2013-05-24 | 6 | 0d |  | [Owner Error] |  |
| 14 | EngineA | 20d | 2013-05-27 | 2013-06-21 | 12, 13 | 5d |  | [Owner Error] |  |
| 15 | EngineB | 25d | 2013-05-27 | 2013-06-28 | 12, 13 | 0d |  | [Owner Error] |  |
| 16 | EngineC | 15d | 2013-05-06 | 2013-05-24 | 6 | 30d | 25d | [Owner Error] |  |
| 17 | ManagerA | 20d | 2013-07-01 | 2013-07-26 | 14, 15, 11, 8, 7 | 0d |  | [Owner Error] |  |
| 18 | ManagerB | 25d | 2013-07-01 | 2013-08-02 | 15, 16, 8, 7 | 5d | 0d | [Owner Error] |  |
| 19 | Client App1 | 25d | 2013-08-05 | 2013-09-06 | 17, 18 | 5d |  | [Owner Error] |  |
| 20 | Client App2 | 35d | 2013-07-29 | 2013-09-13 | 17 | 0d |  | [Owner Error] | Yes |
| 21 | System Testing | 30d | 2013-09-16 | 2013-10-25 | 5, 19, 20 | 0d |  | [Owner Error] | Yes |
