# JAM 8 months

Schedule from MS Project, 2015-01-05 to 2015-08-28, status date 2015-01-05.
--config-- / {"FloatRiskRanges":{"CriticalRange":{"Low":0,"High":1},"RedRange":{"Low":2,"High":9},"YellowRange":{"Low":10,"High":26},"GreenRange":{"Low":27,"High":999}},"CriticalityFactor":4,"CriticalityRedFactor":3,"CriticalityYellowFactor":2,"CriticalityGreenFactor":1,"Mean":0,"CorrectFloats":false,"NumberOfStandardDev":1.0,"ResourceConfiguration":[]} / --endconfig--
--config-- / "FloatRiskRanges":"CriticalRange":"Low":0,"High":1,"RedRange":"Low":2,"High":9,"YellowRange":"Low":10,"High":26,"GreenRange":"Low":27,"High":999,"CriticalityFactor":4,"CriticalityRedFactor":3,"CriticalityYellowFactor":2,"CriticalityGreenFactor":1,"Mean":0,"CorrectFloats":false,"NumberOfStandardDev":1.0,"ResourceConfiguration":[] / --endconfig--

## Calendars

- Standard: Mon-Fri 08:00-12:00, 13:00-17:00; Sat-Sun off.

## Schedule

| ID | Task | Type | Duration | Start | Finish | Predecessors | Total slack | Free slack | PDEx Abnormal Activity | PDEx Message |
| --- | --- | --- | --- | --- | --- | --- | --- | --- | --- | --- |
| 1 | Start | milestone | 0d | 2015-01-05 | 2015-01-05 |  | 0d |  | Yes |  |
| 2 | Requirements |  | 15d | 2015-01-05 | 2015-01-23 | 1 | 15d |  |  | [Owner Error] |
| 3 | Architecture |  | 15d | 2015-01-05 | 2015-01-23 | 1 | 0d |  |  | [Owner Error] |
| 4 | Project Planning |  | 10d | 2015-01-26 | 2015-02-06 | 3 | 0d |  |  | [Owner Error] |
| 5 | Management Education |  | 5d | 2015-02-09 | 2015-02-13 | 4 | 0d |  | Yes | [Owner Error] |
| 6 | SDP Review | milestone | 0d | 2015-02-13 | 2015-02-13 | 5, 2 | 0d |  | Yes |  |
| 7 | UX Design |  | 10d | 2015-03-23 | 2015-04-03 | 17 | 40d | 0d |  | [Owner Error] |
| 8 | Dev Training |  | 5d | 2015-02-16 | 2015-02-20 | 6 | 0d |  | Yes | [Owner Error] |
| 9 | Test Plan |  | 25d | 2015-02-23 | 2015-03-27 | 8 | 65d | 0d | Yes | [Owner Error] |
| 10 | Test Harness |  | 25d | 2015-03-30 | 2015-05-01 | 9 | 65d |  | Yes | [Owner Error] |
| 11 | Build and Setup |  | 10d | 2015-02-16 | 2015-02-27 | 6 | 15d |  |  | [Owner Error] |
| 12 | UI Design |  | 20d | 2015-04-06 | 2015-05-01 | 7 | 40d | 0d | Yes | [Owner Error] |
| 13 | Manual |  | 20d | 2015-05-04 | 2015-05-29 | 12 | 55d |  | Yes | [Owner Error] |
| 14 | Logging |  | 10d | 2015-02-23 | 2015-03-06 | 8 | 10d |  |  | [Owner Error] |
| 15 | Message Bus |  | 15d | 2015-02-23 | 2015-03-13 | 8 | 0d |  |  | [Owner Error] |
| 16 | Security |  | 20d | 2015-02-23 | 2015-03-20 | 8 | 0d |  | Yes | [Owner Error] |
| 17 | Infrastructure Complete | milestone | 0d | 2015-03-20 | 2015-03-20 | 16, 15, 14, 11 | 0d |  | Yes |  |
| 18 | Payments DB |  | 5d | 2015-03-23 | 2015-03-27 | 17 | 45d | 0d | Yes | [Owner Error] |
| 19 | Members DB |  | 5d | 2015-03-23 | 2015-03-27 | 17 | 30d | 0d | Yes | [Owner Error] |
| 20 | Projects DB |  | 5d | 2015-03-23 | 2015-03-27 | 17 | 30d | 0d | Yes | [Owner Error] |
| 21 | Contractors DB |  | 5d | 2015-03-23 | 2015-03-27 | 17 | 30d | 0d | Yes | [Owner Error] |
| 22 | Education DB |  | 5d | 2015-03-23 | 2015-03-27 | 17 | 45d | 0d | Yes | [Owner Error] |
| 23 | Workflows Repository |  | 15d | 2015-03-16 | 2015-04-03 | 15 | 0d |  |  | [Owner Error] |
| 24 | Regulations DB |  | 5d | 2015-03-23 | 2015-03-27 | 17 | 0d |  | Yes | [Owner Error] |
| 25 | Data Migration |  | 10d | 2015-03-30 | 2015-04-10 | 18, 19, 20, 21, 22, 24 | 90d |  |  | [Owner Error] |
| 26 | Payments Access |  | 10d | 2015-03-30 | 2015-04-10 | 18 | 45d |  |  | [Owner Error] |
| 27 | Members Access |  | 10d | 2015-03-30 | 2015-04-10 | 19 | 30d | 0d |  | [Owner Error] |
| 28 | Projects Access |  | 10d | 2015-03-30 | 2015-04-10 | 20 | 30d |  |  | [Owner Error] |
| 29 | Contractors Access |  | 10d | 2015-03-30 | 2015-04-10 | 21 | 30d |  |  | [Owner Error] |
| 30 | Education Access |  | 10d | 2015-03-30 | 2015-04-10 | 22 | 45d |  |  | [Owner Error] |
| 31 | Workflows Access |  | 20d | 2015-04-06 | 2015-05-01 | 23 | 0d |  | Yes | [Owner Error] |
| 32 | Regulations Access |  | 10d | 2015-03-30 | 2015-04-10 | 24 | 0d |  |  | [Owner Error] |
| 33 | Regulations Engine A |  | 30d | 2015-04-13 | 2015-05-22 | 32 | 0d |  | Yes | [Owner Error] |
| 34 | Search Engine |  | 15d | 2015-04-13 | 2015-05-01 | 27 | 30d |  |  | [Owner Error] |
| 35 | Regulations Engine B |  | 15d | 2015-05-25 | 2015-06-12 | 28, 29, 33 | 0d |  |  | [Owner Error] |
| 36 | Abstract Manager |  | 30d | 2015-05-04 | 2015-06-12 | 31, 17 | 0d |  | Yes | [Owner Error] |
| 37 | Membership Manager |  | 10d | 2015-06-15 | 2015-06-26 | 36, 27, 26, 33 | 0d |  |  | [Owner Error] |
| 38 | Market Manager |  | 10d | 2015-06-15 | 2015-06-26 | 36, 28, 34, 35 | 0d |  |  | [Owner Error] |
| 39 | Education Manager |  | 10d | 2015-06-15 | 2015-06-26 | 36, 30 | 0d |  |  | [Owner Error] |
| 40 | Regression Test Harness |  | 10d | 2015-06-15 | 2015-06-26 | 36 | 0d |  |  | [Owner Error] |
| 41 | Managers Complete | milestone | 0d | 2015-06-26 | 2015-06-26 | 37, 38, 39, 40 | 0d |  | Yes |  |
| 42 | Members Portal |  | 15d | 2015-06-29 | 2015-07-17 | 12, 41 | 10d |  |  | [Owner Error] |
| 43 | Contractors Portal |  | 15d | 2015-06-29 | 2015-07-17 | 12, 41 | 10d |  |  | [Owner Error] |
| 44 | Education Portal |  | 10d | 2015-06-29 | 2015-07-10 | 12, 41 | 15d |  |  | [Owner Error] |
| 45 | Marketplace App |  | 25d | 2015-06-29 | 2015-07-31 | 12, 41 | 0d |  | Yes | [Owner Error] |
| 46 | Manual Polishing |  | 10d | 2015-08-03 | 2015-08-14 | 42, 43, 44, 45 | 0d |  |  | [Owner Error] |
| 47 | System Testing |  | 10d | 2015-08-03 | 2015-08-14 | 10, 42, 43, 44, 45 | 0d |  |  | [Owner Error] |
| 48 | System Rollout |  | 10d | 2015-08-17 | 2015-08-28 | 25, 13, 47, 46 | 0d |  |  | [Owner Error] |
| 49 | End | milestone | 0d | 2015-08-28 | 2015-08-28 | 48 | 0d |  | Yes |  |
