# IDesign Inc.

Schedule from MS Project, 2015-01-05 to 2015-08-28, status date 2015-01-05.
--config-- / {"FloatRiskRanges":{"CriticalRange":{"Low":0,"High":1},"RedRange":{"Low":2,"High":9},"YellowRange":{"Low":10,"High":26},"GreenRange":{"Low":27,"High":999}},"CriticalityFactor":4,"CriticalityRedFactor":3,"CriticalityYellowFactor":2,"CriticalityGreenFactor":1,"Mean":0,"CorrectFloats":true,"NumberOfStandardDev":1.0,"ResourceConfiguration":[{"UniqueId":3,"Name":"PJM","IsDeveloper":false,"Phases":["All"],"Count":0,"Class":"PJM","ClassDisplayOrder":1,"ClassColor":"#FF9999FF","CostMultiplier":1.0,"BetweenTasksCost":0},{"UniqueId":1,"Name":"PDM","IsDeveloper":false,"Phases":["All"],"Count":0,"Class":"PDM","ClassDisplayOrder":2,"ClassColor":"#FF990033","CostMultiplier":1.0,"BetweenTasksCost":0},{"UniqueId":2,"Name":"ARC","IsDeveloper":false,"Phases":["All"],"Count":0,"Class":"ARC","ClassDisplayOrder":3,"ClassColor":"#FFFFFF66","CostMultiplier":1.0,"BetweenTasksCost":0},{"UniqueId":14,"Name":"DevOps","IsDeveloper":false,"Phases":["Construction","Release"],"Count":0,"Class":"CM","ClassDisplayOrder":4,"ClassColor":"#FFF79646","CostMultiplier":1.0,"BetweenTasksCost":0},{"UniqueId":11,"Name":"QC1","IsDeveloper":false,"Phases":["Construction","Testing"],"Count":0,"Class":"QC","ClassDisplayOrder":5,"ClassColor":"#FF3399FF","CostMultiplier":1.0,"BetweenTasksCost":0},{"UniqueId":12,"Name":"QC2","IsDeveloper":false,"Phases":["All"],"Count":0,"Class":"QC","ClassDisplayOrder":5,"ClassColor":"#FF3399FF","CostMultiplier":1.0,"BetweenTasksCost":2},{"UniqueId":5,"Name":"DEV1","IsDeveloper":true,"Phases":["Construction"],"Count":0,"Class":"DEV","ClassDisplayOrder":6,"ClassColor":"#FF660033","CostMultiplier":1.0,"BetweenTasksCost":1},{"UniqueId":6,"Name":"DEV2","IsDeveloper":true,"Phases":["Construction"],"Count":0,"Class":"DEV","ClassDisplayOrder":6,"ClassColor":"#FF660033","CostMultiplier":1.0,"BetweenTasksCost":1},{"UniqueId":7,"Name":"DEV3","IsDeveloper":true,"Phases":["Construction"],"Count":0,"Class":"DEV","ClassDisplayOrder":6,"ClassColor":"#FF660033","CostMultiplier":1.0,"BetweenTasksCost":1},{"UniqueId":8,"Name":"DEV4","IsDeveloper":true,"Phases":["Construction"],"Count":0,"Class":"DEV","ClassDisplayOrder":6,"ClassColor":"#FF660033","CostMultiplier":1.0,"BetweenTasksCost":1},{"UniqueId":16,"Name":"DBA","IsDeveloper":true,"Phases":["Construction"],"Count":0,"Class":"DEV","ClassDisplayOrder":6,"ClassColor":"#FF660033","CostMultiplier":1.0,"BetweenTasksCost":1},{"UniqueId":13,"Name":"TE","IsDeveloper":false,"Phases":["All"],"Count":0,"Class":"TE","ClassDisplayOrder":8,"ClassColor":"#FF0000CC","CostMultiplier":1.0,"BetweenTasksCost":2},{"UniqueId":4,"Name":"UX","IsDeveloper":false,"Phases":["All"],"Count":0,"Class":"UX","ClassDisplayOrder":9,"ClassColor":"#FF0000CC","CostMultiplier":1.0,"BetweenTasksCost":2}],"ShowMessageConfiguration":{"ShowAbnormal":true,"ShowMissingPredecessorSuccessor":true,"ShowMissingOwner":true,"ShowDanglingZeroDuration":true,"ShowNotDivisibleByFive":true,"ShowManuallyScheduledTask":true}} / --endconfig--
--config-- / "FloatRiskRanges":"CriticalRange":"Low":0,"High":1,"RedRange":"Low":2,"High":9,"YellowRange":"Low":10,"High":26,"GreenRange":"Low":27,"High":999,"CriticalityFactor":4,"CriticalityRedFactor":3,"CriticalityYellowFactor":2,"CriticalityGreenFactor":1,"Mean":0,"CorrectFloats":true,"NumberOfStandardDev":1.0,"ResourceConfiguration":["UniqueId":3,"Name":"PJM","IsDeveloper":false,"Phases":["All"],"Count":0,"Class":"PJM","ClassDisplayOrder":1,"ClassColor":"#FF9999FF","CostMultiplier":1.0,"BetweenTasksCost":0,"UniqueId":1,"Name":"PDM","IsDeveloper":false,"Phases":["All"],"Count":0,"Class":"PDM","ClassDisplayOrder":2,"ClassColor":"#FF990033","CostMultiplier":1.0,"BetweenTasksCost":0,"UniqueId":2,"Name":"ARC","IsDeveloper":false,"Phases":["All"],"Count":0,"Class":"ARC","ClassDisplayOrder":3,"ClassColor":"#FFFFFF66","CostMultiplier":1.0,"BetweenTasksCost":0,"UniqueId":14,"Name":"DevOps","IsDeveloper":false,"Phases":["Construction","Release"],"Count":0,"Class":"CM","ClassDisplayOrder":4,"ClassColor":"#FFF79646","CostMultiplier":1.0,"BetweenTasksCost":0,"UniqueId":11,"Name":"QC1","IsDeveloper":false,"Phases":["Construction","Testing"],"Count":0,"Class":"QC","ClassDisplayOrder":5,"ClassColor":"#FF3399FF","CostMultiplier":1.0,"BetweenTasksCost":0,"UniqueId":12,"Name":"QC2","IsDeveloper":false,"Phases":["All"],"Count":0,"Class":"QC","ClassDisplayOrder":5,"ClassColor":"#FF3399FF","CostMultiplier":1.0,"BetweenTasksCost":2,"UniqueId":5,"Name":"DEV1","IsDeveloper":true,"Phases":["Construction"],"Count":0,"Class":"DEV","ClassDisplayOrder":6,"ClassColor":"#FF660033","CostMultiplier":1.0,"BetweenTasksCost":1,"UniqueId":6,"Name":"DEV2","IsDeveloper":true,"Phases":["Construction"],"Count":0,"Class":"DEV","ClassDisplayOrder":6,"ClassColor":"#FF660033","CostMultiplier":1.0,"BetweenTasksCost":1,"UniqueId":7,"Name":"DEV3","IsDeveloper":true,"Phases":["Construction"],"Count":0,"Class":"DEV","ClassDisplayOrder":6,"ClassColor":"#FF660033","CostMultiplier":1.0,"BetweenTasksCost":1,"UniqueId":8,"Name":"DEV4","IsDeveloper":true,"Phases":["Construction"],"Count":0,"Class":"DEV","ClassDisplayOrder":6,"ClassColor":"#FF660033","CostMultiplier":1.0,"BetweenTasksCost":1,"UniqueId":16,"Name":"DBA","IsDeveloper":true,"Phases":["Construction"],"Count":0,"Class":"DEV","ClassDisplayOrder":6,"ClassColor":"#FF660033","CostMultiplier":1.0,"BetweenTasksCost":1,"UniqueId":13,"Name":"TE","IsDeveloper":false,"Phases":["All"],"Count":0,"Class":"TE","ClassDisplayOrder":8,"ClassColor":"#FF0000CC","CostMultiplier":1.0,"BetweenTasksCost":2,"UniqueId":4,"Name":"UX","IsDeveloper":false,"Phases":["All"],"Count":0,"Class":"UX","ClassDisplayOrder":9,"ClassColor":"#FF0000CC","CostMultiplier":1.0,"BetweenTasksCost":2],"ShowMessageConfiguration":"ShowAbnormal":true,"ShowMissingPredecessorSuccessor":true,"ShowMissingOwner":true,"ShowDanglingZeroDuration":true,"ShowNotDivisibleByFive":true,"ShowManuallyScheduledTask":true / --endconfig--

## Calendars

- Standard: Mon-Fri 08:00-12:00, 13:00-17:00; Sat-Sun off.

## Resources

| Resource |
| --- |
| PDM |
| ARC |
| PJM |
| UX |
| DEV1 |
| DEV2 |
| DEV3 |
| DEV4 |
| QC1 |
| QC2 |
| TE |
| DevOps |
| DBA |

## Schedule

| ID | Task | Type | Duration | Start | Finish | Predecessors | Total slack | Free slack | Resources | Work | PDEx Phase | PDEx Abnormal Activity | Resource Dependencies | PDEx Message |
| --- | --- | --- | --- | --- | --- | --- | --- | --- | --- | --- | --- | --- | --- | --- |
| 1 | Start | milestone | 0d | 2015-01-05 | 2015-01-05 |  | 0d |  |  |  | Front End | Yes |  |  |
| 2 | Requirements |  | 15d | 2015-01-05 | 2015-01-23 | 1 | 15d |  | PDM | 120h | Front End |  |  |  |
| 3 | Architecture |  | 15d | 2015-01-05 | 2015-01-23 | 1 | 0d |  | ARC | 120h | Front End |  |  |  |
| 4 | Project Planning |  | 10d | 2015-01-26 | 2015-02-06 | 3 | 0d |  | PJM; ARC; PDM | 240h | Front End |  |  |  |
| 5 | Management Education |  | 5d | 2015-02-09 | 2015-02-13 | 4 | 0d |  | PJM; ARC; PDM | 120h | Front End | Yes |  |  |
| 6 | SDP Review | milestone | 0d | 2015-02-13 | 2015-02-13 | 5, 2 | 0d |  | PJM; ARC; PDM |  | Front End | Yes |  |  |
| 7 | UX Design |  | 10d | 2015-03-23 | 2015-04-03 | 17 | 40d | 0d | UX | 80h | Construction |  |  |  |
| 8 | Dev Training |  | 5d | 2015-02-16 | 2015-02-20 | 6 | 0d |  | ARC | 40h | Construction | Yes |  |  |
| 9 | Test Plan |  | 25d | 2015-02-23 | 2015-03-27 | 8 | 65d | 0d | TE | 200h | Construction | Yes |  |  |
| 10 | Test Harness |  | 25d | 2015-03-30 | 2015-05-01 | 9 | 65d |  | TE | 200h | Construction | Yes |  |  |
| 11 | Build and Setup |  | 10d | 2015-02-16 | 2015-02-27 | 6 | 15d |  | DevOps | 80h | Construction |  |  |  |
| 12 | UI Design |  | 20d | 2015-04-06 | 2015-05-01 | 7 | 40d | 0d | UX | 160h | Construction | Yes |  |  |
| 13 | Manual |  | 20d | 2015-05-04 | 2015-05-29 | 12 | 55d |  | PDM | 160h | Construction | Yes |  |  |
| 14 | Logging |  | 10d | 2015-02-23 | 2015-03-06 | 8 | 10d |  | DEV2 | 80h | Construction |  |  |  |
| 15 | Message Bus |  | 15d | 2015-02-23 | 2015-03-13 | 8 | 0d |  | ARC | 120h | Construction |  |  |  |
| 16 | Security |  | 20d | 2015-02-23 | 2015-03-20 | 8 | 0d |  | DEV1 | 160h | Construction | Yes |  |  |
| 17 | Infrastructure Complete | milestone | 0d | 2015-03-20 | 2015-03-20 | 16, 15, 14, 11 | 0d |  |  |  | Construction | Yes |  |  |
| 18 | Payments DB |  | 5d | 2015-04-27 | 2015-05-01 | 17, 22 | 20d | 0d | DBA | 40h | Construction | Yes | 22 |  |
| 19 | Members DB |  | 5d | 2015-03-30 | 2015-04-03 | 17, 24 | 10d | 0d | DBA | 40h | Construction | Yes | 24 |  |
| 20 | Projects DB |  | 5d | 2015-04-06 | 2015-04-10 | 17, 19 | 10d | 0d | DBA | 40h | Construction | Yes | 19 |  |
| 21 | Contractors DB |  | 5d | 2015-04-13 | 2015-04-17 | 17, 20 | 15d | 0d | DBA | 40h | Construction | Yes | 20 |  |
| 22 | Education DB |  | 5d | 2015-04-20 | 2015-04-24 | 17, 21 | 20d | 0d | DBA | 40h | Construction | Yes | 21 |  |
| 23 | Workflows Repository |  | 15d | 2015-03-16 | 2015-04-03 | 15 | 0d |  | ARC | 120h | Construction |  |  |  |
| 24 | Regulations DB |  | 5d | 2015-03-23 | 2015-03-27 | 17 | 0d |  | DBA | 40h | Construction | Yes |  |  |
| 25 | Data Migration |  | 10d | 2015-05-04 | 2015-05-15 | 18, 19, 20, 21, 22, 24 | 65d |  | DBA | 80h | Construction |  |  |  |
| 26 | Payments Access |  | 10d | 2015-05-04 | 2015-05-15 | 18 | 20d |  | DEV3 | 80h | Construction |  |  |  |
| 27 | Members Access |  | 10d | 2015-04-06 | 2015-04-17 | 19 | 15d | 5d | DEV3 | 80h | Construction |  |  |  |
| 28 | Projects Access |  | 10d | 2015-04-13 | 2015-04-24 | 20 | 10d | 0d | DEV4 | 80h | Construction |  |  |  |
| 29 | Contractors Access |  | 10d | 2015-04-20 | 2015-05-01 | 21 | 15d |  | DEV3 | 80h | Construction |  |  |  |
| 30 | Education Access |  | 10d | 2015-05-18 | 2015-05-29 | 22, 34 | 10d |  | DEV4 | 80h | Construction |  | 34 |  |
| 31 | Workflows Access |  | 20d | 2015-04-06 | 2015-05-01 | 23 | 0d |  | DEV1 | 160h | Construction | Yes |  |  |
| 32 | Regulations Access |  | 10d | 2015-03-30 | 2015-04-10 | 24 | 0d |  | DEV2 | 80h | Construction |  |  |  |
| 33 | Regulations Engine A |  | 30d | 2015-04-13 | 2015-05-22 | 32 | 0d |  | DEV2 | 240h | Construction | Yes |  |  |
| 34 | Search Engine |  | 15d | 2015-04-27 | 2015-05-15 | 27, 28 | 10d | 0d | DEV4 | 120h | Construction |  | 28 |  |
| 35 | Regulations Engine B |  | 15d | 2015-05-25 | 2015-06-12 | 28, 29, 33 | 0d |  | DEV2 | 120h | Construction |  |  |  |
| 36 | Abstract Manager |  | 30d | 2015-05-04 | 2015-06-12 | 31, 17 | 0d |  | DEV1 | 240h | Construction | Yes |  |  |
| 37 | Membership Manager |  | 10d | 2015-06-15 | 2015-06-26 | 36, 27, 26, 33 | 0d |  | DEV1 | 80h | Construction |  |  |  |
| 38 | Market Manager |  | 10d | 2015-06-15 | 2015-06-26 | 36, 28, 34, 35 | 0d |  | DEV2 | 80h | Construction |  |  |  |
| 39 | Education Manager |  | 10d | 2015-06-15 | 2015-06-26 | 36, 30 | 0d |  | DEV3 | 80h | Construction |  |  |  |
| 40 | Regression Test Harness |  | 10d | 2015-06-15 | 2015-06-26 | 36 | 0d |  | DEV4 | 80h | Construction |  |  |  |
| 41 | Managers Complete | milestone | 0d | 2015-06-26 | 2015-06-26 | 37, 38, 39, 40 | 0d |  |  |  | Construction | Yes |  |  |
| 42 | Members Portal |  | 15d | 2015-06-29 | 2015-07-17 | 12, 41 | 10d |  | DEV2 | 120h | Construction |  |  |  |
| 43 | Contractors Portal |  | 15d | 2015-06-29 | 2015-07-17 | 12, 41 | 10d |  | DEV3 | 120h | Construction |  |  |  |
| 44 | Education Portal |  | 10d | 2015-06-29 | 2015-07-10 | 12, 41 | 15d |  | DEV4 | 80h | Construction |  |  |  |
| 45 | Marketplace App |  | 25d | 2015-06-29 | 2015-07-31 | 12, 41 | 0d |  | DEV1 | 200h | Construction | Yes |  |  |
| 46 | Manual Polishing |  | 10d | 2015-08-03 | 2015-08-14 | 42, 43, 44, 45 | 0d |  | PDM | 80h | Release |  |  |  |
| 47 | System Testing |  | 10d | 2015-08-03 | 2015-08-14 | 10, 42, 43, 44, 45 | 0d |  | QC1; QC2 | 160h | Testing |  |  |  |
| 48 | System Rollout |  | 10d | 2015-08-17 | 2015-08-28 | 25, 13, 47, 46 | 0d |  | PJM; PDM; ARC; DevOps | 320h | Release |  |  | [Missing Predecessor/Successor] |
| 49 | End | milestone | 0d | 2015-08-28 | 2015-08-28 | 48 | 0d |  |  |  |  | Yes |  |  |

Notes:
- 1: The Detailed Gantt Chart view uses color coding to classify types of activities. This is useful in assignments in maintaining task continuity.
