# IDesign Inc.

Schedule from MS Project, 2015-01-05 to 2015-08-07, status date 2015-01-05.
--config-- / {"FloatRiskRanges":{"CriticalRange":{"Low":0,"High":1},"RedRange":{"Low":2,"High":9},"YellowRange":{"Low":10,"High":26},"GreenRange":{"Low":27,"High":999}},"CriticalityFactor":4,"CriticalityRedFactor":3,"CriticalityYellowFactor":2,"CriticalityGreenFactor":1,"Mean":0,"CorrectFloats":true,"NumberOfStandardDev":1.0,"ResourceConfiguration":[{"UniqueId":3,"Name":"PJM","IsDeveloper":false,"Phases":["All"],"Count":0,"Class":"PJM","ClassDisplayOrder":1,"ClassColor":"#FF9999FF","CostMultiplier":1.0,"BetweenTasksCost":0},{"UniqueId":1,"Name":"PDM","IsDeveloper":false,"Phases":["All"],"Count":0,"Class":"PDM","ClassDisplayOrder":2,"ClassColor":"#FF990033","CostMultiplier":1.0,"BetweenTasksCost":0},{"UniqueId":2,"Name":"ARC","IsDeveloper":false,"Phases":["All"],"Count":0,"Class":"ARC","ClassDisplayOrder":3,"ClassColor":"#FFFFFF99","CostMultiplier":1.0,"BetweenTasksCost":0},{"UniqueId":14,"Name":"DevOps","IsDeveloper":false,"Phases":["Construction","Release","Testing"],"Count":0,"Class":"CM","ClassDisplayOrder":4,"ClassColor":"#FFFF9966","CostMultiplier":1.0,"BetweenTasksCost":0},{"UniqueId":11,"Name":"QC1","IsDeveloper":false,"Phases":["Construction","Testing"],"Count":0,"Class":"QC","ClassDisplayOrder":5,"ClassColor":"#FF9999CC","CostMultiplier":1.0,"BetweenTasksCost":0},{"UniqueId":12,"Name":"QC2","IsDeveloper":false,"Phases":["All"],"Count":0,"Class":"QC","ClassDisplayOrder":5,"ClassColor":"#FF9999CC","CostMultiplier":1.0,"BetweenTasksCost":2},{"UniqueId":5,"Name":"DEV1","IsDeveloper":true,"Phases":["Construction"],"Count":0,"Class":"DEV","ClassDisplayOrder":6,"ClassColor":"#FF660066","CostMultiplier":1.0,"BetweenTasksCost":1},{"UniqueId":6,"Name":"DEV2","IsDeveloper":true,"Phases":["Construction"],"Count":0,"Class":"DEV","ClassDisplayOrder":6,"ClassColor":"#FF660066","CostMultiplier":1.0,"BetweenTasksCost":1},{"UniqueId":7,"Name":"DEV3","IsDeveloper":true,"Phases":["Construction"],"Count":0,"Class":"DEV","ClassDisplayOrder":6,"ClassColor":"#FF660066","CostMultiplier":1.0,"BetweenTasksCost":1},{"UniqueId":8,"Name":"DEV4","IsDeveloper":true,"Phases":["Construction"],"Count":0,"Class":"DEV","ClassDisplayOrder":6,"ClassColor":"#FF660066","CostMultiplier":1.0,"BetweenTasksCost":1},{"UniqueId":9,"Name":"DEV5","IsDeveloper":true,"Phases":["Construction"],"Count":0,"Class":"DEV","ClassDisplayOrder":6,"ClassColor":"#FF660066","CostMultiplier":1.0,"BetweenTasksCost":1},{"UniqueId":16,"Name":"DBA","IsDeveloper":true,"Phases":["Construction"],"Count":0,"Class":"DEV","ClassDisplayOrder":6,"ClassColor":"#FF660066","CostMultiplier":1.0,"BetweenTasksCost":1},{"UniqueId":13,"Name":"TE","IsDeveloper":false,"Phases":["All"],"Count":0,"Class":"TE","ClassDisplayOrder":8,"ClassColor":"#FF0000CC","CostMultiplier":1.0,"BetweenTasksCost":2},{"UniqueId":4,"Name":"UX","IsDeveloper":false,"Phases":["All"],"Count":0,"Class":"UX","ClassDisplayOrder":9,"ClassColor":"#FF0000CC","CostMultiplier":1.0,"BetweenTasksCost":2}],"ShowMessageConfiguration":{"ShowAbnormal":true,"ShowMissingPredecessorSuccessor":true,"ShowMissingOwner":true,"ShowDanglingZeroDuration":true,"ShowNotDivisibleByFive":true,"ShowManuallyScheduledTask":true}} / --endconfig--
--config-- / "FloatRiskRanges":"CriticalRange":"Low":0,"High":1,"RedRange":"Low":2,"High":9,"YellowRange":"Low":10,"High":26,"GreenRange":"Low":27,"High":999,"CriticalityFactor":4,"CriticalityRedFactor":3,"CriticalityYellowFactor":2,"CriticalityGreenFactor":1,"Mean":0,"CorrectFloats":true,"NumberOfStandardDev":1.0,"ResourceConfiguration":["UniqueId":3,"Name":"PJM","IsDeveloper":false,"Phases":["All"],"Count":0,"Class":"PJM","ClassDisplayOrder":1,"ClassColor":"#FF9999FF","CostMultiplier":1.0,"BetweenTasksCost":0,"UniqueId":1,"Name":"PDM","IsDeveloper":false,"Phases":["All"],"Count":0,"Class":"PDM","ClassDisplayOrder":2,"ClassColor":"#FF990033","CostMultiplier":1.0,"BetweenTasksCost":0,"UniqueId":2,"Name":"ARC","IsDeveloper":false,"Phases":["All"],"Count":0,"Class":"ARC","ClassDisplayOrder":3,"ClassColor":"#FFFFFF99","CostMultiplier":1.0,"BetweenTasksCost":0,"UniqueId":14,"Name":"DevOps","IsDeveloper":false,"Phases":["Construction","Release","Testing"],"Count":0,"Class":"CM","ClassDisplayOrder":4,"ClassColor":"#FFFF9966","CostMultiplier":1.0,"BetweenTasksCost":0,"UniqueId":11,"Name":"QC1","IsDeveloper":false,"Phases":["Construction","Testing"],"Count":0,"Class":"QC","ClassDisplayOrder":5,"ClassColor":"#FF9999CC","CostMultiplier":1.0,"BetweenTasksCost":0,"UniqueId":12,"Name":"QC2","IsDeveloper":false,"Phases":["All"],"Count":0,"Class":"QC","ClassDisplayOrder":5,"ClassColor":"#FF9999CC","CostMultiplier":1.0,"BetweenTasksCost":2,"UniqueId":5,"Name":"DEV1","IsDeveloper":true,"Phases":["Construction"],"Count":0,"Class":"DEV","ClassDisplayOrder":6,"ClassColor":"#FF660066","CostMultiplier":1.0,"BetweenTasksCost":1,"UniqueId":6,"Name":"DEV2","IsDeveloper":true,"Phases":["Construction"],"Count":0,"Class":"DEV","ClassDisplayOrder":6,"ClassColor":"#FF660066","CostMultiplier":1.0,"BetweenTasksCost":1,"UniqueId":7,"Name":"DEV3","IsDeveloper":true,"Phases":["Construction"],"Count":0,"Class":"DEV","ClassDisplayOrder":6,"ClassColor":"#FF660066","CostMultiplier":1.0,"BetweenTasksCost":1,"UniqueId":8,"Name":"DEV4","IsDeveloper":true,"Phases":["Construction"],"Count":0,"Class":"DEV","ClassDisplayOrder":6,"ClassColor":"#FF660066","CostMultiplier":1.0,"BetweenTasksCost":1,"UniqueId":9,"Name":"DEV5","IsDeveloper":true,"Phases":["Construction"],"Count":0,"Class":"DEV","ClassDisplayOrder":6,"ClassColor":"#FF660066","CostMultiplier":1.0,"BetweenTasksCost":1,"UniqueId":16,"Name":"DBA","IsDeveloper":true,"Phases":["Construction"],"Count":0,"Class":"DEV","ClassDisplayOrder":6,"ClassColor":"#FF660066","CostMultiplier":1.0,"BetweenTasksCost":1,"UniqueId":13,"Name":"TE","IsDeveloper":false,"Phases":["All"],"Count":0,"Class":"TE","ClassDisplayOrder":8,"ClassColor":"#FF0000CC","CostMultiplier":1.0,"BetweenTasksCost":2,"UniqueId":4,"Name":"UX","IsDeveloper":false,"Phases":["All"],"Count":0,"Class":"UX","ClassDisplayOrder":9,"ClassColor":"#FF0000CC","CostMultiplier":1.0,"BetweenTasksCost":2],"ShowMessageConfiguration":"ShowAbnormal":true,"ShowMissingPredecessorSuccessor":true,"ShowMissingOwner":true,"ShowDanglingZeroDuration":true,"ShowNotDivisibleByFive":true,"ShowManuallyScheduledTask":true / --endconfig--

## Calendars

- Standard: Mon-Fri 08:00-12:00, 13:00-17:00; Sat-Sun off.

## Resources

| Resource |
| --- |
| PDM |
| ARC |
| PJM |
| UX |
| DEV1 |
| DEV2 |
| DEV3 |
| DEV4 |
| DEV5 |
| QC1 |
| QC2 |
| TE |
| DevOps |
| DBA |

## Schedule

| ID | Task | Type | Duration | Start | Finish | Predecessors | Total slack | Free slack | Resources | Work | PDEx Phase | PDEx Abnormal Activity | Resource Dependencies |
| --- | --- | --- | --- | --- | --- | --- | --- | --- | --- | --- | --- | --- | --- |
| 1 | Start | milestone | 0d | 2015-01-05 | 2015-01-05 |  | 0d |  |  |  | Front End | Yes |  |
| 2 | Requirements |  | 15d | 2015-01-05 | 2015-01-23 | 1 | 15d |  | PDM | 120h | Front End |  |  |
| 3 | Architecture |  | 15d | 2015-01-05 | 2015-01-23 | 1 | 0d |  | ARC | 120h | Front End |  |  |
| 4 | Project Planning |  | 10d | 2015-01-26 | 2015-02-06 | 3 | 0d |  | PJM; ARC; PDM | 240h | Front End |  |  |
| 5 | Management Education |  | 5d | 2015-02-09 | 2015-02-13 | 4 | 0d |  | PJM; ARC; PDM | 120h | Front End | Yes |  |
| 6 | SDP Review | milestone | 0d | 2015-02-13 | 2015-02-13 | 5, 3, 2 | 0d |  | PJM; ARC; PDM |  | Front End | Yes |  |
| 7 | UX Design |  | 10d | 2015-02-16 | 2015-02-27 | 6 | 30d |  | UX | 80h | Construction |  |  |
| 8 | Dev Training |  | 5d | 2015-02-16 | 2015-02-20 | 6 | 5d | 0d | ARC | 40h | Construction | Yes |  |
| 9 | Test Plan |  | 25d | 2015-02-23 | 2015-03-27 | 8 | 50d | 0d | TE | 200h | Construction | Yes |  |
| 10 | Test Harness |  | 25d | 2015-03-30 | 2015-05-01 | 9 | 50d |  | TE | 200h | Construction | Yes |  |
| 11 | Build and Setup |  | 10d | 2015-02-16 | 2015-02-27 | 6 | 30d | 25d | DevOps | 80h | Construction |  |  |
| 12 | UI Design |  | 20d | 2015-04-13 | 2015-05-08 | 7, 32 | 0d |  | DEV2 | 160h | Construction | Yes | 32 |
| 13 | Manual |  | 20d | 2015-05-11 | 2015-06-05 | 12 | 35d |  | PDM | 160h | Construction | Yes |  |
| 14 | Logging |  | 10d | 2015-02-23 | 2015-03-06 | 8 | 5d | 0d | DEV1 | 80h | Construction |  |  |
| 15 | Message Bus |  | 15d | 2015-02-23 | 2015-03-13 | 8 | 5d | 0d | ARC | 120h | Construction |  |  |
| 16 | Security |  | 20d | 2015-03-09 | 2015-04-03 | 8, 14 | 5d | 0d | DEV1 | 160h | Construction | Yes | 14 |
| 17 | Infrastructure Complete | milestone | 0d | 2015-04-03 | 2015-04-03 | 16, 15, 14, 11 | 5d | 0d |  |  | Construction | Yes |  |
| 18 | Payments DB |  | 5d | 2015-03-09 | 2015-03-13 | 20 | 0d |  | DBA | 40h | Construction | Yes |  |
| 19 | Members DB |  | 5d | 2015-02-16 | 2015-02-20 | 6 | 0d |  | DBA | 40h | Construction | Yes |  |
| 20 | Projects DB |  | 5d | 2015-03-02 | 2015-03-06 | 21 | 0d |  | DBA | 40h | Construction | Yes |  |
| 21 | Contractors DB |  | 5d | 2015-02-23 | 2015-02-27 | 19 | 0d |  | DBA | 40h | Construction | Yes |  |
| 22 | Education DB |  | 5d | 2015-03-16 | 2015-03-20 | 18 | 0d |  | DBA | 40h | Construction | Yes |  |
| 23 | Workflows Repository |  | 15d | 2015-03-16 | 2015-04-03 | 15 | 5d | 0d | ARC | 120h | Construction |  |  |
| 24 | Regulations DB |  | 5d | 2015-03-23 | 2015-03-27 | 22 | 0d |  | DBA | 40h | Construction | Yes |  |
| 25 | Data Migration |  | 10d | 2015-04-06 | 2015-04-17 | 18, 19, 20, 21, 22, 23, 24 | 70d |  | DBA | 80h | Construction |  |  |
| 26 | Payments Access |  | 10d | 2015-03-30 | 2015-04-10 | 18, 34 | 0d |  | DEV4 | 80h | Construction |  | 34 |
| 27 | Members Access |  | 10d | 2015-02-23 | 2015-03-06 | 19 | 0d |  | DEV2 | 80h | Construction |  |  |
| 28 | Projects Access |  | 10d | 2015-03-16 | 2015-03-27 | 20, 29 | 45d | 40d | DEV3 | 80h | Construction |  | 29 |
| 29 | Contractors Access |  | 10d | 2015-03-02 | 2015-03-13 | 21 | 45d | 0d | DEV3 | 80h | Construction |  |  |
| 30 | Education Access |  | 10d | 2015-03-23 | 2015-04-03 | 22 | 55d | 50d | DEV5 | 80h | Construction |  |  |
| 31 | Workflows Access |  | 20d | 2015-04-06 | 2015-05-01 | 23 | 5d | 0d | DEV1 | 160h | Construction | Yes |  |
| 32 | Regulations Access |  | 10d | 2015-03-30 | 2015-04-10 | 24, 27 | 0d |  | DEV2 | 80h | Construction |  | 27 |
| 33 | Regulations Engine A |  | 30d | 2015-04-13 | 2015-05-22 | 32 | 5d | 0d | ARC | 240h | Construction | Yes |  |
| 34 | Search Engine |  | 15d | 2015-03-09 | 2015-03-27 | 27 | 0d |  | DEV4 | 120h | Construction |  |  |
| 35 | Regulations Engine B |  | 15d | 2015-05-25 | 2015-06-12 | 28, 29, 33 | 5d |  | DEV5 | 120h | Construction |  |  |
| 36 | Abstract Manager |  | 30d | 2015-05-04 | 2015-06-12 | 31, 17 | 5d | 0d | DEV1 | 240h | Construction | Yes |  |
| 37 | Membership Manager |  | 10d | 2015-06-15 | 2015-06-26 | 36, 27, 26, 33, 41 | 5d | 0d | DEV1 | 80h | Construction |  |  |
| 38 | Market Manager |  | 10d | 2015-06-22 | 2015-07-03 | 36, 28, 34, 35, 49, 42 | 0d |  | DEV3 | 80h | Construction |  | 49 |
| 39 | Education Manager |  | 10d | 2015-06-15 | 2015-06-26 | 36, 30, 43 | 5d | 0d | DEV4 | 80h | Construction |  |  |
| 40 | Regression Test Harness |  | 10d | 2015-06-15 | 2015-06-26 | 36, 44 | 5d | 0d | DEV5 | 80h | Construction |  |  |
| 41 | Membership Manager Contract |  | 5d | 2015-04-06 | 2015-04-10 | 17 | 5d | 0d | DEV3 | 40h | Construction | Yes |  |
| 42 | Market Manager Contract |  | 5d | 2015-04-13 | 2015-04-17 | 17, 41 | 5d | 0d | DEV3 | 40h | Construction | Yes | 41 |
| 43 | Education Manager Contract |  | 5d | 2015-04-13 | 2015-04-17 | 17, 26 | 0d |  | DEV4 | 40h | Construction | Yes | 26 |
| 44 | Regression Test Harness Design |  | 5d | 2015-04-06 | 2015-04-10 | 17 | 50d | 45d | ARC | 40h | Construction | Yes |  |
| 45 | Membership Manager Simulator |  | 15d | 2015-04-20 | 2015-05-08 | 41, 43 | 0d |  | DEV4 | 120h | Construction |  | 43 |
| 46 | Market Manager Simulator |  | 15d | 2015-04-20 | 2015-05-08 | 42 | 5d | 0d | DEV3 | 120h | Construction |  |  |
| 47 | Education Manager Simulator |  | 15d | 2015-04-20 | 2015-05-08 | 43 | 5d | 0d | DEV5 | 120h | Construction |  |  |
| 48 | Members Portal |  | 15d | 2015-05-11 | 2015-05-29 | 12, 45 | 0d |  | DEV3 | 120h | Construction |  |  |
| 49 | Contractors Portal |  | 15d | 2015-06-01 | 2015-06-19 | 12, 46, 48 | 0d |  | DEV3 | 120h | Construction |  | 48 |
| 50 | Education Portal |  | 10d | 2015-06-15 | 2015-06-26 | 12, 47, 51 | 5d | 0d | DEV2 | 80h | Construction |  | 51 |
| 51 | Marketplace App |  | 25d | 2015-05-11 | 2015-06-12 | 12, 45, 46, 47 | 5d | 0d | DEV2 | 200h | Construction | Yes |  |
| 52 | Members Portal Integration |  | 5d | 2015-06-29 | 2015-07-03 | 48, 37 | 5d |  | DEV1 | 40h | Construction | Yes |  |
| 53 | Contractors Portal Integration |  | 5d | 2015-07-06 | 2015-07-10 | 49, 38 | 0d |  | DEV3 | 40h | Construction | Yes |  |
| 54 | Education Portal Integration |  | 5d | 2015-06-29 | 2015-07-03 | 50, 39 | 5d |  | DEV4 | 40h | Construction | Yes |  |
| 55 | Marketplace Apps Integration |  | 5d | 2015-06-29 | 2015-07-03 | 51, 40, 50 | 5d |  | DEV2 | 40h | Construction | Yes | 50 |
| 56 | Manual Polishing |  | 10d | 2015-06-29 | 2015-07-10 | 48, 49, 50, 51 | 10d |  | PDM | 80h | Release |  |  |
| 57 | System Testing |  | 10d | 2015-07-13 | 2015-07-24 | 10, 52, 53, 54, 55 | 0d |  | QC1; QC2 | 160h | Testing |  |  |
| 58 | System Rollout |  | 10d | 2015-07-27 | 2015-08-07 | 25, 13, 57, 56 | 0d |  | PJM; PDM; ARC; DevOps | 320h | Release |  |  |

Notes:
- 1: The Detailed Gantt Chart view uses color coding to classify types of activities. This is useful in assignments in maintaining task continuity.
