# IDesign Inc.

Schedule from MS Project, 2015-01-05 to 2015-09-04, status date 2015-01-05.
--config-- / {"FloatRiskRanges":{"CriticalRange":{"Low":0,"High":1},"RedRange":{"Low":2,"High":9},"YellowRange":{"Low":10,"High":26},"GreenRange":{"Low":27,"High":999}},"CriticalityFactor":4,"CriticalityRedFactor":3,"CriticalityYellowFactor":2,"CriticalityGreenFactor":1,"Mean":0,"CorrectFloats":true,"NumberOfStandardDev":1.0,"ResourceConfiguration":[{"UniqueId":3,"Name":"PJM","IsDeveloper":false,"Phases":["All"],"Count":0,"Class":"PJM","ClassDisplayOrder":1,"ClassColor":"#FF9999FF","CostMultiplier":1.0,"BetweenTasksCost":0},{"UniqueId":1,"Name":"PDM","IsDeveloper":false,"Phases":["All"],"Count":0,"Class":"PDM","ClassDisplayOrder":2,"ClassColor":"#FF990033","CostMultiplier":1.0,"BetweenTasksCost":0},{"UniqueId":2,"Name":"ARC","IsDeveloper":false,"Phases":["All"],"Count":0,"Class":"ARC","ClassDisplayOrder":3,"ClassColor":"#FFFFFF99","CostMultiplier":1.0,"BetweenTasksCost":0},{"UniqueId":14,"Name":"DevOps","IsDeveloper":false,"Phases":["Construction","Release","Testing"],"Count":0,"Class":"CM","ClassDisplayOrder":4,"ClassColor":"#FFF79646","CostMultiplier":1.0,"BetweenTasksCost":0},{"UniqueId":31,"Name":"DEV4","IsDeveloper":true,"Phases":["Construction","Release"],"Count":0,"Class":"DEV","ClassDisplayOrder":6,"ClassColor":"#FF660099","CostMultiplier":1.0,"BetweenTasksCost":1},{"UniqueId":11,"Name":"QC1","IsDeveloper":false,"Phases":["Construction","Release","Testing"],"Count":0,"Class":"QC","ClassDisplayOrder":5,"ClassColor":"#FF0099FF","CostMultiplier":1.0,"BetweenTasksCost":0},{"UniqueId":12,"Name":"QC2","IsDeveloper":false,"Phases":["All"],"Count":0,"Class":"QC","ClassDisplayOrder":5,"ClassColor":"#FF0099FF","CostMultiplier":1.0,"BetweenTasksCost":2},{"UniqueId":5,"Name":"DEV1","IsDeveloper":true,"Phases":["Construction","Release"],"Count":0,"Class":"DEV","ClassDisplayOrder":6,"ClassColor":"#FF660099","CostMultiplier":1.0,"BetweenTasksCost":1},{"UniqueId":6,"Name":"DEV2","IsDeveloper":true,"Phases":["Construction","Release"],"Count":0,"Class":"DEV","ClassDisplayOrder":6,"ClassColor":"#FF660099","CostMultiplier":1.0,"BetweenTasksCost":1},{"UniqueId":7,"Name":"DEV3","IsDeveloper":true,"Phases":["Construction","Release"],"Count":0,"Class":"DEV","ClassDisplayOrder":6,"ClassColor":"#FF660099","CostMultiplier":1.0,"BetweenTasksCost":1},{"UniqueId":13,"Name":"TE","IsDeveloper":false,"Phases":["All"],"Count":0,"Class":"TE","ClassDisplayOrder":8,"ClassColor":"#FF0000FF","CostMultiplier":1.0,"BetweenTasksCost":2},{"UniqueId":4,"Name":"UX","IsDeveloper":false,"Phases":["All"],"Count":0,"Class":"UX","ClassDisplayOrder":9,"ClassColor":"#FF0000FF","CostMultiplier":1.0,"BetweenTasksCost":2}],"ShowMessageConfiguration":{"ShowAbnormal":true,"ShowMissingPredecessorSuccessor":true,"ShowMissingOwner":true,"ShowDanglingZeroDuration":true,"ShowNotDivisibleByFive":true,"ShowManuallyScheduledTask":true}} / --endconfig--
--config-- / "FloatRiskRanges":"CriticalRange":"Low":0,"High":1,"RedRange":"Low":2,"High":9,"YellowRange":"Low":10,"High":26,"GreenRange":"Low":27,"High":999,"CriticalityFactor":4,"CriticalityRedFactor":3,"CriticalityYellowFactor":2,"CriticalityGreenFactor":1,"Mean":0,"CorrectFloats":true,"NumberOfStandardDev":1.0,"ResourceConfiguration":["UniqueId":3,"Name":"PJM","IsDeveloper":false,"Phases":["All"],"Count":0,"Class":"PJM","ClassDisplayOrder":1,"ClassColor":"#FF9999FF","CostMultiplier":1.0,"BetweenTasksCost":0,"UniqueId":1,"Name":"PDM","IsDeveloper":false,"Phases":["All"],"Count":0,"Class":"PDM","ClassDisplayOrder":2,"ClassColor":"#FF990033","CostMultiplier":1.0,"BetweenTasksCost":0,"UniqueId":2,"Name":"ARC","IsDeveloper":false,"Phases":["All"],"Count":0,"Class":"ARC","ClassDisplayOrder":3,"ClassColor":"#FFFFFF99","CostMultiplier":1.0,"BetweenTasksCost":0,"UniqueId":14,"Name":"DevOps","IsDeveloper":false,"Phases":["Construction","Release","Testing"],"Count":0,"Class":"CM","ClassDisplayOrder":4,"ClassColor":"#FFF79646","CostMultiplier":1.0,"BetweenTasksCost":0,"UniqueId":31,"Name":"DEV4","IsDeveloper":true,"Phases":["Construction","Release"],"Count":0,"Class":"DEV","ClassDisplayOrder":6,"ClassColor":"#FF660099","CostMultiplier":1.0,"BetweenTasksCost":1,"UniqueId":11,"Name":"QC1","IsDeveloper":false,"Phases":["Construction","Release","Testing"],"Count":0,"Class":"QC","ClassDisplayOrder":5,"ClassColor":"#FF0099FF","CostMultiplier":1.0,"BetweenTasksCost":0,"UniqueId":12,"Name":"QC2","IsDeveloper":false,"Phases":["All"],"Count":0,"Class":"QC","ClassDisplayOrder":5,"ClassColor":"#FF0099FF","CostMultiplier":1.0,"BetweenTasksCost":2,"UniqueId":5,"Name":"DEV1","IsDeveloper":true,"Phases":["Construction","Release"],"Count":0,"Class":"DEV","ClassDisplayOrder":6,"ClassColor":"#FF660099","CostMultiplier":1.0,"BetweenTasksCost":1,"UniqueId":6,"Name":"DEV2","IsDeveloper":true,"Phases":["Construction","Release"],"Count":0,"Class":"DEV","ClassDisplayOrder":6,"ClassColor":"#FF660099","CostMultiplier":1.0,"BetweenTasksCost":1,"UniqueId":7,"Name":"DEV3","IsDeveloper":true,"Phases":["Construction","Release"],"Count":0,"Class":"DEV","ClassDisplayOrder":6,"ClassColor":"#FF660099","CostMultiplier":1.0,"BetweenTasksCost":1,"UniqueId":13,"Name":"TE","IsDeveloper":false,"Phases":["All"],"Count":0,"Class":"TE","ClassDisplayOrder":8,"ClassColor":"#FF0000FF","CostMultiplier":1.0,"BetweenTasksCost":2,"UniqueId":4,"Name":"UX","IsDeveloper":false,"Phases":["All"],"Count":0,"Class":"UX","ClassDisplayOrder":9,"ClassColor":"#FF0000FF","CostMultiplier":1.0,"BetweenTasksCost":2],"ShowMessageConfiguration":"ShowAbnormal":true,"ShowMissingPredecessorSuccessor":true,"ShowMissingOwner":true,"ShowDanglingZeroDuration":true,"ShowNotDivisibleByFive":true,"ShowManuallyScheduledTask":true / --endconfig--

## Calendars

- Standard: Mon-Fri 08:00-12:00, 13:00-17:00; Sat-Sun off.

## Resources

| Resource |
| --- |
| PDM |
| ARC |
| PJM |
| UX |
| DEV1 |
| DEV2 |
| DEV3 |
| QC1 |
| QC2 |
| TE |
| DevOps |
| DEV4 |

## Schedule

| ID | Task | Type | Duration | Start | Finish | Predecessors | Total slack | Free slack | Resources | Work | PDEx Phase | PDEx Abnormal Activity | Resource Dependencies | PDEx Message |
| --- | --- | --- | --- | --- | --- | --- | --- | --- | --- | --- | --- | --- | --- | --- |
| 1 | Start | milestone | 0d | 2015-01-05 | 2015-01-05 |  | 0d |  |  |  | Front End | Yes |  |  |
| 2 | Requirements |  | 15d | 2015-01-05 | 2015-01-23 | 1 | 15d |  | PDM | 120h | Front End |  |  |  |
| 3 | Architecture |  | 15d | 2015-01-05 | 2015-01-23 | 1 | 0d |  | ARC | 120h | Front End |  |  |  |
| 4 | Project Planning |  | 10d | 2015-01-26 | 2015-02-06 | 3 | 0d |  | PJM; ARC; PDM | 240h | Front End |  |  |  |
| 5 | Management Education |  | 5d | 2015-02-09 | 2015-02-13 | 4 | 0d |  | PJM; ARC; PDM | 120h | Front End | Yes |  |  |
| 6 | SDP Review | milestone | 0d | 2015-02-13 | 2015-02-13 | 5, 2 | 0d |  | PJM; ARC; PDM |  | Front End | Yes |  |  |
| 7 | UX Design |  | 10d | 2015-03-23 | 2015-04-03 | 17 | 45d | 0d | UX | 80h | Construction |  |  |  |
| 8 | Dev Training |  | 5d | 2015-02-16 | 2015-02-20 | 6 | 0d |  | ARC | 40h | Construction | Yes |  |  |
| 9 | Test Plan |  | 25d | 2015-02-23 | 2015-03-27 | 8 | 70d | 0d | TE | 200h | Construction | Yes |  |  |
| 10 | Test Harness |  | 25d | 2015-03-30 | 2015-05-01 | 9 | 70d |  | TE | 200h | Construction | Yes |  |  |
| 11 | Build and Setup |  | 10d | 2015-02-16 | 2015-02-27 | 6 | 15d |  | DevOps | 80h | Construction |  |  |  |
| 12 | UI Design |  | 20d | 2015-04-06 | 2015-05-01 | 7 | 45d | 0d | UX | 160h | Construction | Yes |  |  |
| 13 | Manual |  | 20d | 2015-05-04 | 2015-05-29 | 12 | 60d |  | PDM | 160h | Construction | Yes |  |  |
| 14 | Logging |  | 10d | 2015-02-23 | 2015-03-06 | 8 | 10d |  | DEV2 | 80h | Construction |  |  |  |
| 15 | Message Bus |  | 15d | 2015-02-23 | 2015-03-13 | 8 | 5d |  | ARC | 120h | Construction |  |  |  |
| 16 | Security |  | 20d | 2015-02-23 | 2015-03-20 | 8 | 0d |  | DEV1 | 160h | Construction | Yes |  |  |
| 17 | Infrastructure Complete | milestone | 0d | 2015-03-20 | 2015-03-20 | 16, 15, 14, 11 | 0d |  |  |  | Construction | Yes |  |  |
| 18 | Payments DB |  | 5d | 2015-03-23 | 2015-03-27 | 17 | 5d | 0d | DEV1 | 40h | Construction | Yes |  |  |
| 19 | Members DB |  | 5d | 2015-03-23 | 2015-03-27 | 17 | 5d | 0d | DEV2 | 40h | Construction | Yes |  |  |
| 20 | Projects DB |  | 5d | 2015-03-23 | 2015-03-27 | 17 | 10d |  | DEV3 | 40h | Construction | Yes |  |  |
| 21 | Contractors DB |  | 5d | 2015-03-23 | 2015-03-27 | 17 | 10d |  | DEV4 | 40h | Construction | Yes |  |  |
| 22 | Education DB |  | 5d | 2015-03-30 | 2015-04-03 | 17, 18 | 5d |  | DEV1 | 40h | Construction | Yes | 18 |  |
| 23 | Workflows Repository |  | 15d | 2015-03-23 | 2015-04-10 | 17 | 0d |  | ARC | 120h | Construction |  |  |  |
| 24 | Regulations DB |  | 5d | 2015-03-30 | 2015-04-03 | 17, 19 | 5d |  | DEV2 | 40h | Construction | Yes | 19 | [Missing Predecessor/Successor] |
| 25 | DB Complete | milestone | 0d | 2015-04-10 | 2015-04-10 | 18, 19, 20, 21, 22, 23, 24 | 0d |  |  |  | Construction | Yes |  |  |
| 26 | Data Migration |  | 10d | 2015-06-01 | 2015-06-12 | 25, 37 | 50d |  | DEV4 | 80h | Construction |  | 37 |  |
| 27 | Payments Access |  | 10d | 2015-04-13 | 2015-04-24 | 25 | 0d |  | DEV2 | 80h | Construction |  |  |  |
| 28 | Members Access |  | 10d | 2015-04-13 | 2015-04-24 | 25 | 0d |  | DEV3 | 80h | Construction |  |  |  |
| 29 | Projects Access |  | 10d | 2015-04-13 | 2015-04-24 | 25 | 0d |  | DEV4 | 80h | Construction |  |  |  |
| 30 | Contractors Access |  | 10d | 2015-04-27 | 2015-05-08 | 25, 27 | 0d |  | DEV2 | 80h | Construction |  | 27 |  |
| 31 | Education Access |  | 10d | 2015-04-27 | 2015-05-08 | 25, 28 | 0d |  | DEV3 | 80h | Construction |  | 28 |  |
| 32 | Workflows Access |  | 20d | 2015-04-13 | 2015-05-08 | 25 | 0d |  | DEV1 | 160h | Construction | Yes |  |  |
| 33 | Regulations Access |  | 10d | 2015-04-27 | 2015-05-08 | 25, 29 | 0d |  | DEV4 | 80h | Construction |  | 29 |  |
| 34 | RA Complete | milestone | 0d | 2015-05-08 | 2015-05-08 | 27, 28, 29, 30, 31, 32, 33 | 0d |  |  |  | Construction | Yes |  |  |
| 35 | Regulations Engine A |  | 30d | 2015-05-11 | 2015-06-19 | 34 | 0d |  | DEV1 | 240h | Construction | Yes |  |  |
| 36 | Regulations Engine B |  | 15d | 2015-05-11 | 2015-05-29 | 34 | 15d |  | DEV3 | 120h | Construction |  |  |  |
| 37 | Search Engine |  | 15d | 2015-05-11 | 2015-05-29 | 34 | 15d | 0d | DEV4 | 120h | Construction |  |  |  |
| 38 | Emgines Complete | milestone | 0d | 2015-06-19 | 2015-06-19 | 35, 36, 37, 39 | 0d |  |  |  | Construction | Yes |  |  |
| 39 | Abstract Manager |  | 30d | 2015-05-11 | 2015-06-19 | 34 | 0d |  | DEV2 | 240h | Construction | Yes |  |  |
| 40 | Membership Manager |  | 10d | 2015-06-22 | 2015-07-03 | 34, 38 | 0d |  | DEV1 | 80h | Construction |  |  |  |
| 41 | Market Manager |  | 10d | 2015-06-22 | 2015-07-03 | 34, 38 | 0d |  | DEV2 | 80h | Construction |  |  |  |
| 42 | Education Manager |  | 10d | 2015-06-22 | 2015-07-03 | 34, 38 | 0d |  | DEV3 | 80h | Construction |  |  |  |
| 43 | Regression Test Harness |  | 10d | 2015-06-22 | 2015-07-03 | 34, 38 | 0d |  | DEV4 | 80h | Construction |  |  |  |
| 44 | Managers Complete | milestone | 0d | 2015-07-03 | 2015-07-03 | 40, 41, 42, 43 | 0d |  |  |  | Construction | Yes |  |  |
| 45 | Members Portal |  | 15d | 2015-07-06 | 2015-07-24 | 12, 44 | 10d |  | DEV2 | 120h | Construction |  |  |  |
| 46 | Contractors Portal |  | 15d | 2015-07-06 | 2015-07-24 | 12, 44 | 10d |  | DEV3 | 120h | Construction |  |  |  |
| 47 | Education Portal |  | 10d | 2015-07-06 | 2015-07-17 | 12, 44 | 15d |  | DEV4 | 80h | Construction |  |  |  |
| 48 | Marketplace App |  | 25d | 2015-07-06 | 2015-08-07 | 12, 44 | 0d |  | DEV1 | 200h | Construction | Yes |  |  |
| 49 | Clients Complete | milestone | 0d | 2015-08-07 | 2015-08-07 | 45, 46, 47, 48 | 0d |  |  |  |  | Yes |  |  |
| 50 | Manual Polishing |  | 10d | 2015-08-10 | 2015-08-21 | 49 | 0d |  | PDM | 80h | Release |  |  |  |
| 51 | System Testing |  | 10d | 2015-08-10 | 2015-08-21 | 10, 49 | 0d |  | QC1; QC2 | 160h | Testing |  |  |  |
| 52 | System Rollout |  | 10d | 2015-08-24 | 2015-09-04 | 26, 13, 51, 50 | 0d |  | PJM; PDM; ARC; DevOps | 320h | Release |  |  | [Missing Predecessor/Successor] |

Notes:
- 1: The Detailed Gantt Chart view uses color coding to classify types of activities. This is useful in assignments in maintaining task continuity. Also note the use of shade for milestones.
