# IDesign Inc.

Schedule from MS Project, 2013-01-28 to 2013-11-01.
--config-- / {"FloatRiskRanges":{"CriticalRange":{"Low":0,"High":1},"RedRange":{"Low":2,"High":9},"YellowRange":{"Low":10,"High":26},"GreenRange":{"Low":27,"High":999}},"CriticalityFactor":4,"CriticalityRedFactor":3,"CriticalityYellowFactor":2,"CriticalityGreenFactor":1,"Mean":0,"CorrectFloats":false,"NumberOfStandardDev":1.0,"ResourceConfiguration":[{"UniqueId":3,"Name":"Product Manager","IsDeveloper":false,"Phases":["All"],"Count":0,"Class":"PDM","ClassDisplayOrder":0,"ClassColor":"#FF9900CC","CostMultiplier":1.0,"BetweenTasksCost":0},{"UniqueId":7,"Name":"Developer 4","IsDeveloper":true,"Phases":[],"Count":0,"Class":"DEV","ClassDisplayOrder":0,"ClassColor":"#FFFF0000","CostMultiplier":1.0,"BetweenTasksCost":2},{"UniqueId":1,"Name":"Project Manager","IsDeveloper":false,"Phases":["All"],"Count":0,"Class":"PJM","ClassDisplayOrder":1,"ClassColor":"#FF6699FF","CostMultiplier":1.0,"BetweenTasksCost":0},{"UniqueId":2,"Name":"Architect","IsDeveloper":false,"Phases":["All"],"Count":0,"Class":"ARC","ClassDisplayOrder":3,"ClassColor":"#FF009900","CostMultiplier":1.0,"BetweenTasksCost":0},{"UniqueId":15,"Name":"DevOps","IsDeveloper":false,"Phases":["Infrastructure","Construction","Testing"],"Count":0,"Class":"CM","ClassDisplayOrder":4,"ClassColor":"#FFFF9966","CostMultiplier":1.0,"BetweenTasksCost":0},{"UniqueId":4,"Name":"Developer 1","IsDeveloper":true,"Phases":["Infrastructure","Construction"],"Count":0,"Class":"DEV","ClassDisplayOrder":5,"ClassColor":"#FF660066","CostMultiplier":1.0,"BetweenTasksCost":1},{"UniqueId":5,"Name":"Developer 2","IsDeveloper":true,"Phases":["Infrastructure","Construction"],"Count":0,"Class":"DEV","ClassDisplayOrder":5,"ClassColor":"#FF660066","CostMultiplier":1.0,"BetweenTasksCost":1},{"UniqueId":6,"Name":"Developer 3","IsDeveloper":true,"Phases":["Infrastructure","Construction"],"Count":0,"Class":"DEV","ClassDisplayOrder":5,"ClassColor":"#FF660066","CostMultiplier":1.0,"BetweenTasksCost":1},{"UniqueId":11,"Name":"Test Engineer 1","IsDeveloper":false,"Phases":[],"Count":0,"Class":"TE","ClassDisplayOrder":6,"ClassColor":"#FF0000FF","CostMultiplier":1.0,"BetweenTasksCost":2},{"UniqueId":9,"Name":"QC 1","IsDeveloper":false,"Phases":["Construction","Testing"],"Count":0,"Class":"QC","ClassDisplayOrder":7,"ClassColor":"#FFCC0000","CostMultiplier":1.0,"BetweenTasksCost":0},{"UniqueId":10,"Name":"QC 2","IsDeveloper":false,"Phases":[],"Count":0,"Class":"QC","ClassDisplayOrder":7,"ClassColor":"#FFCC0000","CostMultiplier":1.0,"BetweenTasksCost":2},{"UniqueId":12,"Name":"DBA 1","IsDeveloper":true,"Phases":[],"Count":0,"Class":"DB","ClassDisplayOrder":8,"ClassColor":"#FF00FFFF","CostMultiplier":1.0,"BetweenTasksCost":2},{"UniqueId":13,"Name":"DBA2","IsDeveloper":true,"Phases":[],"Count":0,"Class":"DB","ClassDisplayOrder":8,"ClassColor":"#FF00FFFF","CostMultiplier":1.0,"BetweenTasksCost":2}],"ShowMessageConfiguration":{"ShowAbnormal":true,"ShowMissingPredecessorSuccessor":true,"ShowMissingOwner":true,"ShowDanglingZeroDuration":true,"ShowNotDivisibleByFive":true,"ShowManuallyScheduledTask":true}} / --endconfig--
--config-- / "FloatRiskRanges":"CriticalRange":"Low":0,"High":1,"RedRange":"Low":2,"High":9,"YellowRange":"Low":10,"High":26,"GreenRange":"Low":27,"High":999,"CriticalityFactor":4,"CriticalityRedFactor":3,"CriticalityYellowFactor":2,"CriticalityGreenFactor":1,"Mean":0,"CorrectFloats":false,"NumberOfStandardDev":1.0,"ResourceConfiguration":["UniqueId":3,"Name":"Product Manager","IsDeveloper":false,"Phases":["All"],"Count":0,"Class":"PDM","ClassDisplayOrder":0,"ClassColor":"#FF9900CC","CostMultiplier":1.0,"BetweenTasksCost":0,"UniqueId":7,"Name":"Developer 4","IsDeveloper":true,"Phases":[],"Count":0,"Class":"DEV","ClassDisplayOrder":0,"ClassColor":"#FFFF0000","CostMultiplier":1.0,"BetweenTasksCost":2,"UniqueId":1,"Name":"Project Manager","IsDeveloper":false,"Phases":["All"],"Count":0,"Class":"PJM","ClassDisplayOrder":1,"ClassColor":"#FF6699FF","CostMultiplier":1.0,"BetweenTasksCost":0,"UniqueId":2,"Name":"Architect","IsDeveloper":false,"Phases":["All"],"Count":0,"Class":"ARC","ClassDisplayOrder":3,"ClassColor":"#FF009900","CostMultiplier":1.0,"BetweenTasksCost":0,"UniqueId":15,"Name":"DevOps","IsDeveloper":false,"Phases":["Infrastructure","Construction","Testing"],"Count":0,"Class":"CM","ClassDisplayOrder":4,"ClassColor":"#FFFF9966","CostMultiplier":1.0,"BetweenTasksCost":0,"UniqueId":4,"Name":"Developer 1","IsDeveloper":true,"Phases":["Infrastructure","Construction"],"Count":0,"Class":"DEV","ClassDisplayOrder":5,"ClassColor":"#FF660066","CostMultiplier":1.0,"BetweenTasksCost":1,"UniqueId":5,"Name":"Developer 2","IsDeveloper":true,"Phases":["Infrastructure","Construction"],"Count":0,"Class":"DEV","ClassDisplayOrder":5,"ClassColor":"#FF660066","CostMultiplier":1.0,"BetweenTasksCost":1,"UniqueId":6,"Name":"Developer 3","IsDeveloper":true,"Phases":["Infrastructure","Construction"],"Count":0,"Class":"DEV","ClassDisplayOrder":5,"ClassColor":"#FF660066","CostMultiplier":1.0,"BetweenTasksCost":1,"UniqueId":11,"Name":"Test Engineer 1","IsDeveloper":false,"Phases":[],"Count":0,"Class":"TE","ClassDisplayOrder":6,"ClassColor":"#FF0000FF","CostMultiplier":1.0,"BetweenTasksCost":2,"UniqueId":9,"Name":"QC 1","IsDeveloper":false,"Phases":["Construction","Testing"],"Count":0,"Class":"QC","ClassDisplayOrder":7,"ClassColor":"#FFCC0000","CostMultiplier":1.0,"BetweenTasksCost":0,"UniqueId":10,"Name":"QC 2","IsDeveloper":false,"Phases":[],"Count":0,"Class":"QC","ClassDisplayOrder":7,"ClassColor":"#FFCC0000","CostMultiplier":1.0,"BetweenTasksCost":2,"UniqueId":12,"Name":"DBA 1","IsDeveloper":true,"Phases":[],"Count":0,"Class":"DB","ClassDisplayOrder":8,"ClassColor":"#FF00FFFF","CostMultiplier":1.0,"BetweenTasksCost":2,"UniqueId":13,"Name":"DBA2","IsDeveloper":true,"Phases":[],"Count":0,"Class":"DB","ClassDisplayOrder":8,"ClassColor":"#FF00FFFF","CostMultiplier":1.0,"BetweenTasksCost":2],"ShowMessageConfiguration":"ShowAbnormal":true,"ShowMissingPredecessorSuccessor":true,"ShowMissingOwner":true,"ShowDanglingZeroDuration":true,"ShowNotDivisibleByFive":true,"ShowManuallyScheduledTask":true / --endconfig--

## Calendars

- Standard: Mon-Fri 08:00-12:00, 13:00-17:00; Sat-Sun off.

## Resources

| Resource |
| --- |
| Project Manager |
| Architect |
| Product Manager |
| Developer 1 |
| Developer 2 |
| Developer 3 |
| Developer 4 |
| QC 1 |
| QC 2 |
| Test Engineer 1 |
| DBA 1 |
| DBA2 |
| DevOps |

## Schedule

| ID | Task | Type | Duration | Start | Finish | Predecessors | Total slack | Free slack | Resources | Work | PDEx Phase | PDEx Abnormal Activity |
| --- | --- | --- | --- | --- | --- | --- | --- | --- | --- | --- | --- | --- |
| 1 | Requirements |  | 15d | 2013-01-28 | 2013-02-15 |  | 0d |  | Architect | 120h | Front End |  |
| 2 | Architecture |  | 20d | 2013-02-18 | 2013-03-15 | 1 | 0d |  | Architect | 160h | Front End |  |
| 3 | Project Design |  | 20d | 2013-03-18 | 2013-04-12 | 2 | 0d |  | Architect | 160h | Front End |  |
| 4 | Test Plan |  | 30d | 2013-04-15 | 2013-05-24 | 22 | 50d | 0d | Test Engineer 1 | 240h | Infrastructure | Yes |
| 5 | Test Harness |  | 35d | 2013-05-27 | 2013-07-12 | 4 | 50d |  | Test Engineer 1 | 280h | Construction | Yes |
| 6 | Logging |  | 15d | 2013-04-15 | 2013-05-03 | 22 | 5d |  | Developer 2 | 120h | Infrastructure |  |
| 7 | Security |  | 20d | 2013-04-15 | 2013-05-10 | 22 | 0d |  | Developer 3 | 160h | Infrastructure |  |
| 8 | Pub/Sub |  | 5d | 2013-04-15 | 2013-04-19 | 22 | 15d |  | Developer 1 | 40h | Infrastructure | Yes |
| 9 | Resource A |  | 20d | 2013-04-15 | 2013-05-10 | 22 | 30d | 0d | DBA2 | 160h | Infrastructure |  |
| 10 | Resource B |  | 15d | 2013-04-15 | 2013-05-03 | 22 | 15d | 5d | DBA 1 | 120h | Infrastructure |  |
| 11 | Resource Access A |  | 10d | 2013-05-13 | 2013-05-24 | 9, 23 | 30d |  | Developer 3 | 80h | Construction | Yes |
| 12 | Resource Access B |  | 5d | 2013-05-13 | 2013-05-17 | 10, 23 | 10d |  | Developer 2 | 40h | Construction | Yes |
| 13 | Resource Access C |  | 15d | 2013-05-13 | 2013-05-31 | 23 | 0d |  | Developer 1 | 120h | Construction |  |
| 14 | EngineA |  | 20d | 2013-06-03 | 2013-06-28 | 12, 13 | 5d |  | Developer 1 | 160h | Construction |  |
| 15 | EngineB |  | 25d | 2013-06-03 | 2013-07-05 | 12, 13 | 0d |  | Developer 2 | 200h | Construction |  |
| 16 | EngineC |  | 15d | 2013-05-13 | 2013-05-31 | 23 | 30d | 25d | Developer 4 | 120h | Construction |  |
| 17 | ManagerA |  | 20d | 2013-07-08 | 2013-08-02 | 14, 15, 11 | 0d |  | Developer 1 | 160h | Construction |  |
| 18 | ManagerB |  | 25d | 2013-07-08 | 2013-08-09 | 15, 16 | 5d | 0d | Developer 2 | 200h | Construction |  |
| 19 | Client App1 |  | 25d | 2013-08-12 | 2013-09-13 | 17, 18 | 5d |  | Developer 2 | 200h | Construction |  |
| 20 | Client App2 |  | 35d | 2013-08-05 | 2013-09-20 | 17 | 0d |  | Developer 1 | 280h | Construction | Yes |
| 21 | System Testing |  | 30d | 2013-09-23 | 2013-11-01 | 5, 19, 20 | 0d |  | QC 1; QC 2 | 480h | Testing | Yes |
| 22 | M0 | milestone | 0d | 2013-04-12 | 2013-04-12 | 3 | 0d |  |  |  | Front End | Yes |
| 23 | M1 | milestone | 0d | 2013-05-10 | 2013-05-10 | 6, 7, 8 | 0d |  |  |  | Infrastructure | Yes |
